# Vorlage_Strassenbau

Schedule from MS Project, 2011-01-10 to 2011-01-13.

## Calendars

- Standard: Mon-Fri 08:00-12:00, 13:00-17:00; Sat-Sun off.

## Schedule

| ID | WBS | Task | Type | Duration | Start | Finish | Predecessors | Total slack |
| --- | --- | --- | --- | --- | --- | --- | --- | --- |
| 1 | 1 | **Straßenerneuerung** |  | 3.19d | 2011-01-10 08:00 | 2011-01-13 09:30 |  | 0d |
| 2 | 1.1 | Aufstellen der Lichtsignalanlage |  | 1h | 2011-01-10 08:00 | 2011-01-10 09:00 |  | 0d |
| 3 | 1.2 | Sperren der Straßenkreuzung |  | 0.5h | 2011-01-10 09:00 | 2011-01-10 09:30 | 2 | 0d |
| 4 | 1.3 | **Straßenabbau** |  | 0.81d | 2011-01-10 09:30 | 2011-01-10 17:00 |  | 0d |
| 5 | 1.3.1 | Bereit zum Abriss | milestone | 0d | 2011-01-10 09:30 | 2011-01-10 09:30 | 3 | 0d |
| 6 | 1.3.2 | Abtragen Asphalt |  | 4h | 2011-01-10 09:30 | 2011-01-10 14:30 | 5 | 0d |
| 7 | 1.3.3 | Abtragen Unterbau |  | 2.5h | 2011-01-10 14:30 | 2011-01-10 17:00 | 6 | 0d |
| 8 | 1.3.4 | Fahrbahnspur entfernt | milestone | 0d | 2011-01-10 17:00 | 2011-01-10 17:00 | 7 | 0d |
| 9 | 1.4 | Schreddern |  | 4h | 2011-01-11 08:00 | 2011-01-11 12:00 | 8 | 0d |
| 10 | 1.5 | Einbringen Wasser/Abwasser/Energie |  | 4h | 2011-01-11 13:00 | 2011-01-11 17:00 | 9 | 0d |
| 11 | 1.6 | **Straßenaufbau** |  | 1d | 2011-01-11 17:00 | 2011-01-12 17:00 |  | 0d |
| 12 | 1.6.1 | Bereit zum Aufbau | milestone | 0d | 2011-01-11 17:00 | 2011-01-11 17:00 | 10 | 0d |
| 13 | 1.6.2 | Auftragen Unterbau |  | 3h | 2011-01-12 08:00 | 2011-01-12 11:00 | 12 | 0d |
| 14 | 1.6.3 | Verdichten |  | 1h | 2011-01-12 11:00 | 2011-01-12 12:00 | 13 | 0d |
| 15 | 1.6.4 | Auftragen Asphalt |  | 3h | 2011-01-12 13:00 | 2011-01-12 16:00 | 14 | 0d |
| 16 | 1.6.5 | Verdichten |  | 1h | 2011-01-12 16:00 | 2011-01-12 17:00 | 15 | 0d |
| 17 | 1.6.6 | Fahrbahnspur fertig | milestone | 0d | 2011-01-12 17:00 | 2011-01-12 17:00 | 16 | 0d |
| 18 | 1.7 | Abbau der Straßensperre |  | 0.5h | 2011-01-13 08:00 | 2011-01-13 08:30 | 17 | 0d |
| 19 | 1.8 | Befahrbarkeit gewährleistet | milestone | 0d | 2011-01-13 08:30 | 2011-01-13 08:30 | 18 | 0d |
| 20 | 1.9 | Abbau der Lichtsignalanlage |  | 1h | 2011-01-13 08:30 | 2011-01-13 09:30 | 19 | 0d |
| 21 | 1.10 | Projektende | milestone | 0d | 2011-01-13 09:30 | 2011-01-13 09:30 | 20 | 0d |
