# Badsanierung

Schedule from MS Project, 2013-02-18 to 2013-03-01.
Microsoft

## Calendars

- Standard: Mon-Fri 08:00-12:00, 13:00-17:00; Sat-Sun off.

## Resources

| Resource | Rate |
| --- | --- |
| Maler | 40 |
| Installateur | 50 |
| Fliesenleger | 40 |
| Elektroniker | 50 |
| Maurer | 35 |
| Bauleiter | 60 |

## Schedule

| ID | WBS | Task | Type | Duration | Start | Finish | Predecessors | Total slack |
| --- | --- | --- | --- | --- | --- | --- | --- | --- |
| 1 | 1 | **Demontage** |  | 1.25d | 2013-02-18 08:00 | 2013-02-19 10:00 |  | 0d |
| 2 | 1.1 | Folie ausgelegt und abgeklebt |  | 2h | 2013-02-18 08:00 | 2013-02-18 10:00 |  | 0d |
| 3 | 1.2 | Wasserversorgung abgestellt und die Wasserleitungen entleert |  | 1h | 2013-02-18 10:00 | 2013-02-18 11:00 | 2 | 0d |
| 4 | 1.3 | Wasser- und Abwasserleitungen verdichten |  | 1h | 2013-02-18 11:00 | 2013-02-18 12:00 | 3 | 0d |
| 5 | 1.4 | Objekte demontieren |  | 2h | 2013-02-18 13:00 | 2013-02-18 15:00 | 4 | 0d |
| 6 | 1.5 | Fliesen entfernen |  | 4h | 2013-02-18 15:00 | 2013-02-19 10:00 | 5 | 0d |
| 7 | 1.6 | Ende Demontage | milestone | 0d | 2013-02-19 10:00 | 2013-02-19 10:00 | 6 | 0d |
| 8 | 2 | **Neumontage** |  | 8.25d | 2013-02-19 10:00 | 2013-03-01 12:00 |  | 0d |
| 9 | 2.1 | Neumontage von Wasser- und Abwasserleitungen |  | 1.5d | 2013-02-19 10:00 | 2013-02-20 15:00 | 7 | 0d |
| 10 | 2.2 | Stromleitungen und Steckdosen verlegt |  | 1d | 2013-02-19 10:00 | 2013-02-20 10:00 | 7 | 0.5d |
| 11 | 2.3 | Wandschlitze geschlossen und Unebenheiten beseitigt |  | 1d | 2013-02-20 15:00 | 2013-02-21 15:00 | 9, 10 | 0d |
| 12 | 2.4 | Badewanne werden gestellt und angeschlossen |  | 3h | 2013-02-21 15:00 | 2013-02-22 09:00 | 11 | 0d |
| 13 | 2.5 | Badewanne ausgemauert |  | 2h | 2013-02-22 09:00 | 2013-02-22 11:00 | 12 | 0d |
| 14 | 2.6 | Wände und der Boden gefließt bzw. verfugt |  | 2d | 2013-02-22 11:00 | 2013-02-26 11:00 | 13 | 0d |
| 15 | 2.7 | Spanndecke einbauen |  | 1d | 2013-02-27 11:00 | 2013-02-28 11:00 | 14FS+1ed | 0d |
| 16 | 2.8 | Montage der Objekte und Installation der Armaturen |  | 1d | 2013-02-28 11:00 | 2013-03-01 11:00 | 15 | 0d |
| 17 | 2.9 | Montage der elektronischen Endgeräte |  | 5h | 2013-02-28 11:00 | 2013-02-28 17:00 | 15 | 0.38d |
| 18 | 2.10 | Endabnahme |  | 1h | 2013-03-01 11:00 | 2013-03-01 12:00 | 16, 17 | 0d |
| 19 | 2.11 | Projektende | milestone | 0d | 2013-03-01 12:00 | 2013-03-01 12:00 | 18 | 0d |
