# Lösung Hausbau 7

Schedule from MS Project, 2011-08-15 to 2012-03-14, costs in €.

## Calendars

- Standard: Mon-Fri 08:00-12:00, 13:00-17:00; Sat-Sun off. Exceptions (off unless hours are given): 2011-12-26 to 2011-12-30 (Baustopp).

## Resources

| Resource | Rate |
| --- | --- |
| Tiefbauer | 40 |
| Zimmermann | 45 |
| Dachdecker | 45 |
| Estrichverleger | 40 |
| Putzer | 40 |
| Fliesenleger | 50 |
| Maler | 40 |
| Fußbodenleger | 45 |
| Trockenbauer | 45 |
| Elektriker | 50 |
| Sanitärrohrleger/Klempner | 50 |
| Maurer | 45 |
| Heizungsrohrleger | 50 |
| Fenstermonteur | 50 |
| Tischler | 50 |
| Gärtner | 40 |

## Schedule

| ID | Task | Type | Duration | Start | Finish | Predecessors | Total slack | Free slack | Resources | Work | Cost |
| --- | --- | --- | --- | --- | --- | --- | --- | --- | --- | --- | --- |
| 1 | Baubeginn | milestone | 0d | 2011-08-15 | 2011-08-15 |  | 0d |  |  |  |  |
| 2 | Erdbauarbeiten |  | 2w | 2011-08-15 | 2011-08-26 | 1 | 0d |  | Tiefbauer [300%] | 240h | 9,600 |
| 3 | Rohbauarbeiten |  | 8w | 2011-08-22 | 2011-10-14 | 2FS-1w | 0d |  | Maurer [500%] | 1600h | 72,000 |
| 4 | Holzbauarbeiten |  | 2w | 2011-10-10 | 2011-10-21 | 3FS-1w | 0d |  | Zimmermann [400%] | 320h | 14,400 |
| 5 | Klempnereiarbeiten |  | 1w | 2011-10-17 | 2011-10-21 | 4FS-1w | 98d |  | Sanitärrohrleger/Klempner [200%] | 80h | 4,000 |
| 6 | Dachdeckungsarbeiten |  | 1w | 2011-10-17 | 2011-10-21 | 4FS-1w | 98d |  | Dachdecker [300%] | 120h | 5,400 |
| 7 | Verglasungsarbeiten |  | 1w | 2011-10-17 | 2011-10-21 | 4SS+1w | 0d |  | Fenstermonteur [200%] | 80h | 4,000 |
| 8 | Heizungsarbeiten (Grobinstallation) |  | 3w | 2011-10-24 | 2011-11-11 | 7 | 0d |  | Heizungsrohrleger [300%] | 360h | 18,000 |
| 9 | Sanitärarbeiten (Grobinstallation) |  | 3w | 2011-10-24 | 2011-11-11 | 7 | 10d |  | Sanitärrohrleger/Klempner [200%] | 240h | 12,000 |
| 10 | Elektroarbeiten (Grobinstallation) |  | 3w | 2011-10-24 | 2011-11-11 | 7 | 10d |  | Elektriker [200%] | 240h | 12,000 |
| 11 | Putz- und Stuckarbeiten |  | 3w | 2011-10-10 | 2011-10-28 | 3FS-1w | 10d |  | Putzer [300%] | 360h | 14,400 |
| 12 | Heizungsarbeiten (Feininstallation) |  | 2w | 2011-11-14 | 2011-11-25 | 11, 8 | 0d |  | Elektriker [300%] | 240h | 12,000 |
| 13 | Estricharbeiten |  | 1w | 2011-11-28 | 2011-12-02 | 11, 12, 8, 9, 10 | 0d |  | Estrichverleger [300%] | 120h | 4,800 |
| 14 | Haustür montieren |  | 2h | 2011-11-25 | 2011-11-28 | 13SF | 38d | 10d | Fenstermonteur [200%] | 4h | 200 |
| 15 | Fenster montieren |  | 1w | 2011-12-12 | 2011-12-16 | 13FS+1w, 14 | 28d | 0d | Fenstermonteur [200%] | 80h | 4,000 |
| 16 | Rolläden montieren |  | 1w | 2011-12-19 | 2011-12-23 | 13FS+1w, 15 | 28d | 0d | Fenstermonteur [200%] | 80h | 4,000 |
| 17 | Treppenbau |  | 1w | 2011-12-12 | 2011-12-16 | 13FS+1w | 18d | 0d | Tischler [200%] | 80h | 4,000 |
| 18 | Treppengeländer montieren |  | 1w | 2011-12-19 | 2011-12-23 | 17 | 18d | 0d | Tischler [200%] | 80h | 4,000 |
| 19 | Fliesen- und Plattenarbeiten |  | 3w | 2011-12-12 | 2012-01-06 | 13FS+1w | 0d |  | Fliesenleger [200%] | 240h | 12,000 |
| 20 | Tischlerarbeiten |  | 1w | 2012-01-02 | 2012-01-06 | 18 | 18d |  | Tischler [200%] | 80h | 4,000 |
| 21 | Sanitärarbeiten (Grobinstallation) |  | 2w | 2012-01-12 | 2012-01-25 | 19FS+3d | 4d | 0d | Sanitärrohrleger/Klempner [200%] | 160h | 8,000 |
| 22 | Elektroarbeiten (Grobinstallation) |  | 3w | 2012-01-12 | 2012-02-01 | 19FS+3d | 0d |  | Elektriker [200%] | 240h | 12,000 |
| 23 | Silikonverfugung |  | 1d | 2012-01-26 | 2012-01-26 | 21 | 4d |  | Fliesenleger [200%] | 16h | 800 |
| 24 | Malerarbeiten |  | 4w | 2012-02-02 | 2012-02-29 | 20, 22, 23 | 0d |  | Maler [400%] | 640h | 25,600 |
| 25 | Bodenbelagsarbeiten |  | 2w | 2012-02-23 | 2012-03-14 | 24FS-1w | 0d |  | Fußbodenleger [300%] | 240h | 10,800 |
| 26 | Außenputzarbeiten |  | 2w | 2012-01-02 | 2012-01-13 | 16 | 28d | 0d | Putzer [300%] | 240h | 9,600 |
| 27 | Landschaftsbauarbeiten |  | 2w | 2012-01-23 | 2012-02-03 | 26FS+1w | 28d |  | Gärtner [300%] | 240h | 9,600 |
| 28 | Übergabe | milestone | 0d | 2012-03-14 | 2012-03-14 | 25, 27 | 0d |  |  |  |  |
