# Loesung - Wandtafelergänzung

Schedule from MS Project, 2011-01-10 to 2011-01-13, costs in €.

## Calendars

- Standard: Mon-Fri 08:00-12:00, 13:00-17:00; Sat-Sun off.

## Resources

| Resource | Rate | Cost per use |
| --- | --- | --- |
| Elektromonteur | 41 |  |
| Elektromaterial |  | 190 |
| Maler | 35 |  |
| Malermaterial |  | 105 |

## Schedule

| ID | WBS | Task | Type | Duration | Start | Finish | Predecessors | Total slack | Free slack | Constraint | Resources | Work | Cost |
| --- | --- | --- | --- | --- | --- | --- | --- | --- | --- | --- | --- | --- | --- |
| 1 | 1 | **Fertige Plakatwand** |  | 3.62d | 2011-01-10 08:00 | 2011-01-13 14:00 |  | 0d |  |  |  | 32h | 1,085 |
| 2 | 1.1 | Wand spachteln |  | 4h | 2011-01-10 08:00 | 2011-01-10 12:00 |  | 0.5d |  |  | Maler [200%]; Malermaterial | 12h | 385 |
| 3 | 1.2 | Wand streichen |  | 4h | 2011-01-11 08:00 | 2011-01-11 12:00 | 2FS+6eh | 0d |  |  | Maler [200%] | 8h | 280 |
| 4 | 1.3 | Fertig zum Kleben | milestone | 0d | 2011-01-11 14:00 | 2011-01-11 14:00 | 3FS+2eh | 0d |  |  |  |  |  |
| 5 | 1.4 | Plakate kleben |  | 3h | 2011-01-11 14:00 | 2011-01-11 17:00 | 4 | 0d |  |  | Maler [200%] | 6h | 210 |
| 6 | 1.5 | Laminieren |  | 3h | 2011-01-11 15:30 | 2011-01-12 09:30 | 5SS+5% | 1.44d | 0d |  | Maler [200%] | 6h | 210 |
| 7 | 1.6 | Plakatwand steht | milestone | 0d | 2011-01-12 09:30 | 2011-01-12 09:30 | 6 | 1.44d |  |  |  |  |  |
| 8 | 1.7 | Werbung schalten |  | 2d | 2011-01-11 14:00 | 2011-01-13 14:00 | 5SS | 0d |  |  |  |  |  |
| 9 | 1.8 | Projektende | milestone | 0d | 2011-01-13 14:00 | 2011-01-13 14:00 | 6, 8 | 0d |  |  |  |  |  |
| 10 | 2 | **Beleuchtung** |  | 0.47d | 2011-01-13 08:00 | 2011-01-13 11:45 |  | 0.16d |  |  |  | 5.5h | 415.5 |
| 11 | 2.1 | Lampe anbauen |  | 1h | 2011-01-13 08:00 | 2011-01-13 09:00 |  | 0.16d | 0d | start no earlier than 2011-01-13 08:00 | Elektromonteur; Elektromaterial | 1h | 231 |
| 12 | 2.2 | Dämmerungsschalter installieren |  | 0.5h | 2011-01-13 09:00 | 2011-01-13 09:30 | 11 | 0.16d | 0d |  | Elektromonteur | 0.5h | 20.5 |
| 13 | 2.3 | Dose setzen |  | 0.5h | 2011-01-13 09:30 | 2011-01-13 10:00 | 12 | 0.16d | 0d |  | Elektromonteur | 0.5h | 20.5 |
| 14 | 2.4 | Leitung verlegen |  | 0.5h | 2011-01-13 10:00 | 2011-01-13 10:30 | 13 | 0.16d | 0d |  | Elektromonteur [200%] | 1h | 41 |
| 15 | 2.5 | Installation |  | 1h | 2011-01-13 10:30 | 2011-01-13 11:30 | 14 | 0.16d | 0d |  | Elektromonteur [200%] | 2h | 82 |
| 16 | 2.6 | Funktionsprüfung |  | 0.25h | 2011-01-13 11:30 | 2011-01-13 11:45 | 15 | 0.16d | 0d |  | Elektromonteur [200%] | 0.5h | 20.5 |
| 17 | 2.7 | Beleuchtung i.O. | milestone | 0d | 2011-01-13 11:45 | 2011-01-13 11:45 | 16 | 0.16d |  |  |  |  |  |
