# vorlage_meilenstein

Schedule from MS Project, 2011-01-14 to 2011-01-21, costs in €.

## Calendars

- Standard: Mon-Fri 08:00-12:00, 13:00-17:00; Sat-Sun off.

## Resources

| Resource | Rate |
| --- | --- |
| Umzug und Transport | 30 |
| Malerei Türk | 40 |
| Glaserei Bast | 35 |
| Heizung & Sanitär | 35 |

## Schedule

| ID | WBS | Task | Duration | Start | Finish | Predecessors | Total slack | Free slack | Resources | Work | Cost |
| --- | --- | --- | --- | --- | --- | --- | --- | --- | --- | --- | --- |
| 1 | 1 | **VOLLSANIERUNG** | 6d | 2011-01-14 08:00 | 2011-01-21 17:00 |  | 0d |  |  | 176h | 6,080 |
| 2 | 1.1 | **Wohnzimmer** | 5d | 2011-01-14 08:00 | 2011-01-20 17:00 |  | 0d |  |  | 88h | 3,040 |
| 3 | 1.1.1 | Ausräumen WoZi | 0.5d | 2011-01-14 08:00 | 2011-01-14 12:00 |  | 0d |  | Umzug und Transport [300%] | 12h | 360 |
| 4 | 1.1.2 | Fensterausbau WoZi | 0.5d | 2011-01-14 13:00 | 2011-01-14 17:00 | 3 | 0d |  | Glaserei Bast [200%] | 8h | 280 |
| 5 | 1.1.3 | Heizg.ausbau WoZi | 0.5d | 2011-01-17 08:00 | 2011-01-17 12:00 | 4 | 0d |  | Heizung & Sanitär [200%] | 8h | 280 |
| 6 | 1.1.4 | Fenstereinbau WoZi | 1d | 2011-01-17 13:00 | 2011-01-18 12:00 | 5 | 0d |  | Glaserei Bast [200%] | 16h | 560 |
| 7 | 1.1.5 | Maler WoZi | 1d | 2011-01-18 13:00 | 2011-01-19 12:00 | 6 | 0d |  | Malerei Türk [200%] | 16h | 640 |
| 8 | 1.1.6 | Heizg.einbau WoZi | 1d | 2011-01-19 13:00 | 2011-01-20 12:00 | 7 | 0d |  | Heizung & Sanitär [200%] | 16h | 560 |
| 9 | 1.1.7 | Einräumen WoZi | 0.5d | 2011-01-20 13:00 | 2011-01-20 17:00 | 8 | 0.5d |  | Umzug und Transport [300%] | 12h | 360 |
| 10 | 1.2 | **Küche / Bad** | 5.5d | 2011-01-14 13:00 | 2011-01-21 17:00 |  | 0d |  |  | 88h | 3,040 |
| 11 | 1.2.1 | Ausräumen Kü / Bad | 0.5d | 2011-01-14 13:00 | 2011-01-14 17:00 | 3 | 0.5d | 0d | Umzug und Transport [300%] | 12h | 360 |
| 12 | 1.2.2 | Fensterausbau Kü / Bad | 0.5d | 2011-01-17 08:00 | 2011-01-17 12:00 | 11, 4 | 0.5d | 0d | Glaserei Bast [200%] | 8h | 280 |
| 13 | 1.2.3 | Heizg.ausbau Kü / Bad | 0.5d | 2011-01-17 13:00 | 2011-01-17 17:00 | 12, 5 | 0.5d |  | Heizung & Sanitär [200%] | 8h | 280 |
| 14 | 1.2.4 | Fenstereinbau Kü / Bad | 1d | 2011-01-18 13:00 | 2011-01-19 12:00 | 13, 6 | 0d |  | Glaserei Bast [200%] | 16h | 560 |
| 15 | 1.2.5 | Maler Kü / Bad | 1d | 2011-01-19 13:00 | 2011-01-20 12:00 | 14, 7 | 0d |  | Malerei Türk [200%] | 16h | 640 |
| 16 | 1.2.6 | Heizg.einbau Kü / Bad | 1d | 2011-01-20 13:00 | 2011-01-21 12:00 | 15, 8 | 0d |  | Heizung & Sanitär [200%] | 16h | 560 |
| 17 | 1.2.7 | Einräumen Kü / Bad | 0.5d | 2011-01-21 13:00 | 2011-01-21 17:00 | 16 | 0d |  | Umzug und Transport [300%] | 12h | 360 |
