# Lösung Hausbau 7

Schedule from MS Project, 2013-03-11 to 2013-10-02, costs in €.

## Calendars

- Standard: Mon-Fri 08:00-12:00, 13:00-17:00; Sat-Sun off.

## Resources

| Resource | Rate |
| --- | --- |
| Tiefbauer | 50 |
| Zimmermann | 45 |
| Dachdecker | 45 |
| Estrichverleger | 40 |
| Putzer | 40 |
| Fliesenleger | 50 |
| Maler | 40 |
| Fußbodenleger | 45 |
| Trockenbauer | 45 |
| Elektriker | 50 |
| Sanitärrohrleger/Klempner | 50 |
| Maurer | 45 |
| Heizungsrohrleger | 50 |
| Fenstermonteur | 50 |
| Tischler | 50 |
| Gärtner | 40 |

## Schedule

| ID | Task | Type | Duration | Start | Finish | Predecessors | Total slack | Free slack | Resources | Work | Cost |
| --- | --- | --- | --- | --- | --- | --- | --- | --- | --- | --- | --- |
| 1 | Baubeginn | milestone | 0d | 2013-03-11 | 2013-03-11 |  | 0d |  |  |  |  |
| 2 | Erdbauarbeiten |  | 2w | 2013-03-11 | 2013-03-22 | 1 | 0d |  | Tiefbauer [300%] | 240h | 12,000 |
| 3 | Rohbauarbeiten |  | 8w | 2013-03-18 | 2013-05-10 | 2FS-1w | 0d |  | Maurer [500%] | 1600h | 72,000 |
| 4 | Holzbauarbeiten |  | 2w | 2013-05-06 | 2013-05-17 | 3FS-1w | 0d |  | Zimmermann [400%] | 320h | 14,400 |
| 5 | Klempnereiarbeiten |  | 1w | 2013-05-13 | 2013-05-17 | 4FS-1w | 98d |  | Sanitärrohrleger/Klempner [200%] | 80h | 4,000 |
| 6 | Dachdeckungsarbeiten |  | 1w | 2013-05-13 | 2013-05-17 | 4FS-1w | 98d |  | Dachdecker [300%] | 120h | 5,400 |
| 7 | Verglasungsarbeiten |  | 1w | 2013-05-13 | 2013-05-17 | 4SS+1w | 0d |  | Fenstermonteur [200%] | 80h | 4,000 |
| 8 | Heizungsarbeiten (Grobinstallation) |  | 3w | 2013-05-20 | 2013-06-07 | 7 | 0d |  | Heizungsrohrleger [300%] | 360h | 18,000 |
| 9 | Sanitärarbeiten (Grobinstallation) |  | 3w | 2013-05-20 | 2013-06-07 | 7 | 10d |  | Sanitärrohrleger/Klempner [200%] | 240h | 12,000 |
| 10 | Elektroarbeiten (Grobinstallation) |  | 3w | 2013-05-20 | 2013-06-07 | 7 | 10d |  | Elektriker [200%] | 240h | 12,000 |
| 11 | Putz- und Stuckarbeiten |  | 3w | 2013-05-06 | 2013-05-24 | 3FS-1w | 10d |  | Putzer [300%] | 360h | 14,400 |
| 12 | Heizungsarbeiten (Feininstallation) |  | 2w | 2013-06-10 | 2013-06-21 | 11, 8 | 0d |  | Elektriker [300%] | 240h | 12,000 |
| 13 | Estricharbeiten |  | 1w | 2013-06-24 | 2013-06-28 | 11, 12, 8, 9, 10 | 0d |  | Estrichverleger [300%] | 120h | 4,800 |
| 14 | Haustür montieren |  | 2h | 2013-06-21 | 2013-06-24 | 13SF | 38d | 10d | Fenstermonteur [200%] | 4h | 200 |
| 15 | Fenster montieren |  | 1w | 2013-07-08 | 2013-07-12 | 13FS+1w, 14 | 28d | 0d | Fenstermonteur [200%] | 80h | 4,000 |
| 16 | Rolläden montieren |  | 1w | 2013-07-15 | 2013-07-19 | 13FS+1w, 15 | 28d | 0d | Fenstermonteur [200%] | 80h | 4,000 |
| 17 | Treppenbau |  | 1w | 2013-07-08 | 2013-07-12 | 13FS+1w | 18d | 0d | Tischler [200%] | 80h | 4,000 |
| 18 | Treppengeländer montieren |  | 1w | 2013-07-15 | 2013-07-19 | 17 | 18d | 0d | Tischler [200%] | 80h | 4,000 |
| 19 | Fliesen- und Plattenarbeiten |  | 3w | 2013-07-08 | 2013-07-26 | 13FS+1w | 0d |  | Fliesenleger [200%] | 240h | 12,000 |
| 20 | Tischlerarbeiten |  | 1w | 2013-07-22 | 2013-07-26 | 18 | 18d |  | Tischler [200%] | 80h | 4,000 |
| 21 | Sanitärarbeiten (Grobinstallation) |  | 2w | 2013-08-01 | 2013-08-14 | 19FS+3d | 4d | 0d | Sanitärrohrleger/Klempner [200%] | 160h | 8,000 |
| 22 | Elektroarbeiten (Grobinstallation) |  | 3w | 2013-08-01 | 2013-08-21 | 19FS+3d | 0d |  | Elektriker [200%] | 240h | 12,000 |
| 23 | Silikonverfugung |  | 1d | 2013-08-15 | 2013-08-15 | 21 | 4d |  | Fliesenleger [200%] | 16h | 800 |
| 24 | Malerarbeiten |  | 4w | 2013-08-22 | 2013-09-18 | 20, 22, 23 | 0d |  | Maler [400%] | 640h | 25,600 |
| 25 | Bodenbelagsarbeiten |  | 2w | 2013-09-12 | 2013-10-02 | 24FS-1w | 0d |  | Fußbodenleger [300%] | 240h | 10,800 |
| 26 | Außenputzarbeiten |  | 2w | 2013-07-22 | 2013-08-02 | 16 | 28d | 0d | Putzer [300%] | 240h | 9,600 |
| 27 | Landschaftsbauarbeiten |  | 2w | 2013-08-12 | 2013-08-23 | 26FS+1w | 28d |  | Gärtner [300%] | 240h | 9,600 |
| 28 | Übergabe | milestone | 0d | 2013-10-02 | 2013-10-02 | 25, 27 | 0d |  |  |  |  |
